# workplan_sp&r

Schedule from MS Project, 2009-01-01 to 2011-04-30, 7 hours a day, costs in $, A marks actual dates.
Department of Transportation

## Calendars

- Standard: Mon-Fri 08:00-12:00, 13:00-17:00; Sat-Sun off.

## Resources

| Resource | Group | Rate |
| --- | --- | --- |
| Eng. Apps. |  |  |
| Researh |  |  |
| Div. Researh |  |  |
| FHWA |  |  |
| OIS |  |  |
| On-Call |  |  |
| On-Call Services |  |  |
| Eng. Apps |  |  |
| Contract Admin. |  |  |
| Consultant Services |  |  |
| * Bentley ELS Agreement |  |  |
| Engineering Apps. |  |  |
| Eng Apps |  |  |
| Bentley ELS |  |  |
| Offsite Training |  |  |
| DAS? |  |  |
| Eng. Apps. and OIS |  |  |
| RPA |  |  |
| Consultant Services or OIS |  |  |
| Bentley/OIS |  |  |
| TBD |  |  |
| Consultant Services or Eng. Applications |  |  |
| OIS and Eng. Apps |  |  |
| OIS - PC Support |  |  |
| OIS - Communications |  |  |
| OIS - Programming |  |  |
| OIS - Management |  |  |
| DOIT/OIS |  |  |
| DOIT |  |  |
| Bentley/OIS/Eng. Apps |  |  |
| Pratt William S. | Eng. Apps | 80 |
| Bergeron Eric S. | Eng. Apps | 75 |
| Sparks Chris L. | OIS CADD | 75 |
| Seitz Robert L. | OIS CADD | 75 |
| Ryan Michael E. | OIS CADD | 75 |
| Servidone Anthony | Engineering Applications | 75 |
| Rinaldi John S. | Eng. Apps | 75 |
| William Pratt | OIS | 75 |
| Richard Elaine H. | Eng. Apps | 75 |
| Sardinskas Greg A. | Eng. Apps | 75 |
| Annino Julie M. | Eng. Apps | 75 |
| Jay Christopher D. | OIS | 75 |
| Goodwin James E. | OIS | 75 |
| Goodwin Alberta A. | OIS | 75 |
| Bolden Betty A. | Eng. Apps | 75 |
| Bourgoin Bruce | Eng. Apps | 75 |
| Zimmerman Kathleen A. | Eng. Apps | 75 |
| Trudeau Katherine W. | OIS Manager | 80 |
| Romero Jose L. | OIS Manager | 80 |
| Joe Garafolo |  |  |
| Chris Jay |  |  |
| OIS |  |  |
| Molina John |  |  |
| Project Steering Committee |  |  |
| Charlie Dew |  |  |
| Martin Rose |  |  |
| Marilyn Goslawski |  |  |
| Zimmerman Kathleen |  |  |
| Goodwin Albert |  |  |
| Zimmerman |  |  |
| Kathleen; Goodwin |  |  |
| Alberta |  |  |
| Kathy Zimmerman |  |  |
| Alberta Goodwin |  |  |
| Jim Fallon |  |  |
| Bill Pratt |  |  |
| Joe Garofalo |  |  |
| John Lee |  |  |
| Kate Trudeau |  |  |
| Jim Goodwin |  |  |
| C Jay |  |  |
| L Kalinowski |  |  |
| John Molina |  |  |
| PSC |  |  |

## Schedule

| ID | WBS | Task | Duration | Start | Finish | Complete | Remaining | Total slack | Constraint | Resources | Work | Actual work | Cost | Actual cost |
| --- | --- | --- | --- | --- | --- | --- | --- | --- | --- | --- | --- | --- | --- | --- |
| 1 | 1 | **AASHTO TRNS.PORT UPGRADE AND IMPLEMENTATION PLAN** | 693.71d | 2009-01-01 A | 2011-04-30 | 14% | 593.26d | 0d |  |  | 19827h | 13252.7h | 291,300 | 257,850 |
| 2 | 1.1 | **Subtask 1A - DOIT SDM Business Issues Phase Deliverables** | 210.14d | 2009-01-01 A | 2009-09-15 | 99% | 1.98d | 483.57d |  |  | 12039h | 11988.2h | 257,850 | 257,850 |
| 3 | 1.1.1 | Project Profile | 99.29d | 2009-01-01 A | 2009-05-01 A | 100% |  |  | start no earlier than 2009-02-02 | Molina John; Zimmerman Kathleen A. | 1390h | 1390h | 52,125 | 52,125 |
| 4 | 1.1.2 | Project Team Wheel | 87.86d | 2009-02-12 A | 2009-05-29 A | 100% |  |  | finish no earlier than 2008-02-21 | Molina John; Zimmerman Kathleen A. | 1230h | 1230h | 46,125 | 46,125 |
| 5 | 1.1.3 | Project Team Contact List | 92.43d | 2009-02-11 A | 2009-06-03 A | 100% |  |  | start no earlier than 2008-02-08 | Molina John; Zimmerman Kathleen A. | 1294h | 1294h | 48,525 | 48,525 |
| 6 | 1.1.4 | Project Management Plan | 93.57d | 2009-02-09 A | 2009-06-02 A | 100% |  |  | start no earlier than 2009-02-09 | Zimmerman Kathleen A.; Molina John | 1310h | 1310h | 49,125 | 49,125 |
| 7 | 1.1.5 | Solution Approach | 5d | 2009-02-26 A | 2009-03-04 A | 100% |  |  | start no earlier than 2009-02-26 | Molina John; Zimmerman Kathleen A. | 70h | 70h | 2,625 | 2,625 |
| 8 | 1.1.6 | Cost Benefit Analysis | 113d | 2009-02-25 A | 2009-07-13 A | 100% |  |  | finish no earlier than 2009-07-13 | Zimmerman Kathleen A.; Molina John | 1582h | 1582h | 59,325 | 59,325 |
| 9 | 1.1.7 | **Identify/Address technical concerns/issues** | 153d | 2009-03-12 A | 2009-09-15 | 97% | 3.83d | 483.57d |  | OIS; Molina John | 5116h | 5065.18h |  |  |
| 10 | 1.1.7.1 | Identify license costs and procure: pg 1, #1 | 10.49w | 2009-03-12 A | 2009-05-14 A | 100% |  |  | finish no earlier than 2009-05-14 | Alberta Goodwin; Kathy Zimmerman | 734h | 734h |  |  |
| 11 | 1.1.7.2 | Contracting board issue on info tech: page 1, #2 | 2w | 2009-03-12 A | 2009-03-24 A | 100% |  |  | start no earlier than 2009-03-12 | Jim Fallon | 70h | 70h |  |  |
| 12 | 1.1.7.3 | Question for DAS regarding bid express contract: page 1, #3 | 30.6w | 2009-03-12 A | 2009-09-15 A | 100% |  |  | finish no earlier than 2010-02-01 | Jim Fallon; Bill Pratt | 2142h | 2142h |  |  |
| 13 | 1.1.7.4 | Can DOT sign document w/ terms and conditions with Info Tech: page 1, #4 | 2w | 2009-03-12 A | 2009-03-24 A | 100% |  |  | start no earlier than 2009-03-12 | Jim Fallon; Bill Pratt | 140h | 140h |  |  |
| 14 | 1.1.7.5 | AASHTO Contract for next FY | 15.06w | 2009-03-12 A | 2009-06-11 | 90% | 1.51w | 561.29d | finish no earlier than 2009-06-11 |  |  |  |  |  |
| 15 | 1.1.8 | Phase End Decision Point Meeting | 6.71d | 2009-08-24 A | 2009-08-31 A | 100% |  |  | finish no earlier than 2009-06-05 | PSC | 47h | 47h |  |  |
| 16 | 1.2 | **Subtask 1B - DOIT Business Requirements Phase Deliverables** | 61.57d | 2009-09-16 A | 2009-11-30 | 12% | 54.12d | 421.86d |  |  | 7758h | 1264.5h | 32,325 |  |
| 17 | 1.2.1 | Project Team Wheel | 61.57d | 2009-09-16 | 2009-11-30 |  |  | 421.86d | finish no earlier than 2009-11-30 |  |  |  |  |  |
| 18 | 1.2.2 | Business Process Model | 61.57d | 2009-09-16 | 2009-11-30 |  |  | 421.86d | finish no earlier than 2009-11-30 |  |  |  |  |  |
| 19 | 1.2.3 | Deployment Stategy and Plan | 61.57d | 2009-09-16 | 2009-11-30 |  |  | 421.86d | finish no earlier than 2009-11-30 |  |  |  |  |  |
| 20 | 1.2.4 | Functional Requirements Workbook | 61.57d | 2009-09-16 | 2009-11-30 |  |  | 421.86d | finish no earlier than 2009-11-30 |  |  |  |  |  |
| 21 | 1.2.5 | Non-Functional Requirements Workbook | 61.57d | 2009-09-16 | 2009-11-30 |  |  | 421.86d | finish no earlier than 2009-11-30 |  |  |  |  |  |
| 22 | 1.2.6 | Proof of Concept Evaluation Form | 61.57d | 2009-09-16 | 2009-11-30 |  |  | 421.86d | finish no earlier than 2009-11-30 |  |  |  |  |  |
| 23 | 1.2.7 | Solution Alternatives Document | 38.71d | 2009-09-16 | 2009-11-02 |  |  | 444.71d | start no earlier than 2009-09-16 |  |  |  |  |  |
| 24 | 1.2.8 | Technical Requirements Document | 61.57d | 2009-09-16 | 2009-11-30 |  |  | 421.86d | finish no earlier than 2009-11-30 |  |  |  |  |  |
| 25 | 1.2.9 | Technical Requirements Workbook | 61.57d | 2009-09-16 | 2009-11-30 |  |  | 421.86d | finish no earlier than 2009-11-30 |  |  |  |  |  |

Notes:
- 3: To be reviewed
- 4: To be reviewed
- 5: To be reviewed
- 6: To be reviewed
- 7: To be reviewed
- 8: To be reviewed
- 10: Cost = $3,449.16, reqs written waiting approval
- 11: No conflic w state contracting board
- 13: done w/ tech requirements document s/b same with AASHTO master agreement
- 14: will know costs in mid April

| ID | WBS | Task | Duration | Start | Finish | Complete | Remaining | Baseline start | Baseline finish | Baseline duration | Total slack | Constraint | Resources | Work | Actual work | Cost | Baseline cost |
| --- | --- | --- | --- | --- | --- | --- | --- | --- | --- | --- | --- | --- | --- | --- | --- | --- | --- |
| 26 | 1.2.10 | **Identify/Address technical concerns/issues** | 61.57d | 2009-09-16 A | 2009-11-30 | 21% | 48.6d |  |  |  | 421.86d |  |  | 6896h | 1264.5h |  |  |
| 27 | 1.2.10.1 | Identify/Address technical concerns/issues: Page 3, #11 | 3.08mo | 2009-09-16 A | 2009-11-30 | 19% | 2.48mo |  |  |  | 421.86d | finish no earlier than 2009-11-30 | Kathy Zimmerman | 431h | 84h |  |  |
| 28 | 1.2.10.2 | How many users on Expedite System, why not server edition: page 2, #2 | 12.31w | 2009-09-16 A | 2009-11-30 | 63% | 4.57w |  |  |  | 421.86d | finish no earlier than 2009-11-30 | Kathy Zimmerman | 431h | 271h |  |  |
| 29 | 1.2.10.3 | Info Tech recommendation of using Apache vs IIS: page 2, #3 | 12.31w | 2009-09-16 A | 2009-11-30 | 12% | 10.81w |  |  |  | 421.86d | finish no earlier than 2009-11-30 | Joe Garofalo | 431h | 52.5h |  |  |
| 30 | 1.2.10.4 | OIS standards Info Tech doesn’t support: page 2, #4 (Kate to write up) | 12.31w | 2009-09-16 A | 2009-11-30 | 8% | 11.31w |  |  |  | 421.86d | finish no earlier than 2009-11-30 | Kathy Zimmerman; John Lee | 862h | 70h |  |  |
| 31 | 1.2.10.5 | Info Tech references use of Oracle 10.2.0.3 we use 10.2.0.3. acceptable?: Page 2, #7 | 12.31w | 2009-09-16 A | 2009-11-30 | 63% | 4.57w |  |  |  | 421.86d | finish no earlier than 2009-11-30 | Chris Jay | 431h | 271h |  |  |
| 32 | 1.2.10.6 | Crystal Reports compatibility: page 2, #5 | 12.31w | 2009-09-16 A | 2009-11-30 | 19% | 9.91w |  |  |  | 421.86d | finish no earlier than 2009-11-30 | John Lee | 431h | 84h |  |  |
| 33 | 1.2.10.7 | Estimator requires installation/use of Pearl Scripting, DOT uses VB (TRB meeting): page 2, #8 | 12.31w | 2009-09-16 A | 2009-11-30 | 7% | 11.41w |  |  |  | 421.86d | finish no earlier than 2009-11-30 | Kate Trudeau; John Molina | 862h | 63h |  |  |
| 34 | 1.2.10.8 | VPN access: page 3, #9 | 12.31w | 2009-09-16 A | 2009-11-30 | 4% | 11.81w |  |  |  | 421.86d | finish no earlier than 2009-11-30 | Joe Garofalo; Jim Goodwin | 862h | 35h |  |  |
| 35 | 1.2.10.9 | ConnDOT chose to forgo standard change management activity: Page 3 #10 | 12.31w | 2009-09-16 A | 2009-11-30 | 63% | 4.57w |  |  |  | 421.86d | finish no earlier than 2009-11-30 | Jim Fallon | 431h | 271h |  |  |
| 36 | 1.2.10.10 | Interfaces with CORECT (ongoing discussions date tbd): page 5, #1 | 3.08mo | 2009-09-16 | 2009-11-30 |  |  |  |  |  | 421.86d | finish no earlier than 2009-11-30 | Jim Fallon | 431h |  |  |  |
| 37 | 1.2.10.11 | Tech Resources, detailed specs from Info Tech on experience needed from IT: page 4, all | 12.31w | 2009-09-16 A | 2009-11-30 | 15% | 10.51w |  |  |  | 421.86d | finish no earlier than 2009-11-30 | Kathy Zimmerman | 431h | 63h |  |  |
| 38 | 1.2.10.12 | Legacy Systems: depth of involvement from Info Tech in conversion: Page 5, # 2,3 & 5 | 12.31w | 2009-09-16 | 2009-11-30 |  |  |  |  |  | 421.86d | finish no earlier than 2009-11-30 | Jim Fallon | 431h |  |  |  |
| 39 | 1.2.10.13 | Procuring software for IT development SAS BAMS/DSS | 12.31w | 2009-09-16 | 2009-11-30 |  |  |  |  |  | 421.86d | finish no earlier than 2009-11-30 | Kathy Zimmerman | 431h |  |  |  |
| 40 | 1.2.11 | Phase End Decision Point Meeting | 61.57d | 2009-09-16 | 2009-11-30 |  |  |  |  |  | 421.86d | finish no earlier than 2009-11-30 | Zimmerman Kathleen A.; Molina John | 862h |  | 32,325 |  |
| 41 | 1.3 | **Subtask 1C - DOIT Design Phase Deliverables** | 73.14d | 2009-12-01 | 2010-02-26 |  |  | 2008-05-05 | 2027-01-08 | 5571.22d | 348.57d |  |  |  |  |  | 652,692.49 |
| 42 | 1.3.1 | Configuration Management Plan | 73.14d | 2009-12-01 | 2010-02-26 |  |  | 2008-05-05 | 2008-06-20 | 40d | 348.57d | start no earlier than 2009-12-01 |  |  |  |  | 26,250 |
| 43 | 1.3.2 | Conversion Design Document | 73d | 2009-12-01 | 2010-02-26 |  |  | 2008-05-05 | 2008-05-20 | 13.33d | 348.71d | finish no earlier than 2010-02-26 |  |  |  |  | 14,000 |
| 44 | 1.3.3 | Design Phase MS Project WBS Template | 73d | 2009-12-01 | 2010-02-26 |  |  | 2009-01-05 | 2009-02-05 | 26.67d | 348.71d | finish no earlier than 2010-02-26 |  |  |  |  | 28,000 |
| 45 | 1.3.4 | Design Phase Project Team Wheel | 73d | 2009-12-01 | 2010-02-26 |  |  | 2008-09-22 | 2027-01-08 | 5456.94d | 348.71d | finish no earlier than 2010-02-26 |  |  |  |  | 318,193.99 |
| 46 | 1.3.5 | General Design Decision Point Meeting | 73d | 2009-12-01 | 2010-02-26 |  |  | 2008-08-06 | 2009-03-18 | 182.86d | 348.71d | finish no earlier than 2010-02-26 |  |  |  |  | 31,500 |
| 47 | 1.3.6 | Release Strategy Plan | 73d | 2009-12-01 | 2010-02-26 |  |  | 2008-08-06 | 2009-03-18 | 182.86d | 348.71d | finish no earlier than 2010-02-26 |  |  |  |  | 31,500 |
| 48 | 1.3.7 | Requirments Traceability Mix | 73d | 2009-12-01 | 2010-02-26 |  |  | 2008-08-06 | 2009-03-18 | 182.86d | 348.71d | finish no earlier than 2010-02-26 |  |  |  |  | 31,500 |
| 49 | 1.3.8 | System Design Document | 73d | 2009-12-01 | 2010-02-26 |  |  | 2008-08-06 | 2009-03-18 | 182.86d | 348.71d | finish no earlier than 2010-02-26 |  |  |  |  | 31,500 |
| 50 | 1.3.9 | System Security Profile | 73d | 2009-12-01 | 2010-02-26 |  |  | 2008-08-06 | 2009-03-18 | 182.86d | 348.71d | finish no earlier than 2010-02-26 |  |  |  |  | 31,500 |
| 51 | 1.3.10 | Test Strategy and Plan | 73d | 2009-12-01 | 2010-02-26 |  |  | 2008-08-06 | 2009-03-18 | 182.86d | 348.71d | finish no earlier than 2010-02-26 |  |  |  |  | 31,500 |
| 52 | 1.3.11 | Phase End Decision Point Meeting | 73d | 2009-12-01 | 2010-02-26 |  |  |  |  |  | 348.71d | finish no earlier than 2010-02-26 |  |  |  |  |  |

Notes:
- 27: some issues defined in business issues phase
- 28: no server edition exists, only 1-3 people
- 29: meeting to be set up w John Vittner (TRB) - Jose, needs follow up when phase 2 starts
- 30: Kathy in contact w TTF on OS standards (ie. 2008)
- 31: Should be fine per Mark Douglas
- 32: reponse from Mark Douglas to be reviewd by A Goodwin
- 33: Info Tech to implement, no OIS resources reqrd. Little involvment post implementation
- 34: meeting to be set up w John Vittner (TRB) - Jose
- 36: on going - tbd
- 37: 2 technical FTE required per Mark Douglas based on past projects
- 38: DOT to write dump prgms from legacy, Info Tech to proivde mapping and upload into trns.port. Jim Fallon to handle legal questions

| ID | WBS | Task | Duration | Start | Finish | Baseline start | Baseline finish | Baseline duration | Total slack | Constraint | Baseline cost |
| --- | --- | --- | --- | --- | --- | --- | --- | --- | --- | --- | --- |
| 53 | 1.4 | **Subtask 1D - DOIT Construction Phase Deliverables** | 175.86d | 2010-03-01 | 2010-09-30 | 2008-07-11 | 2010-01-15 | 452.14d? | 172.71d |  | 5,905,525 |
| 54 | 1.4.1 | Backup and Recovery Plan | 175.86d | 2010-03-01 | 2010-09-30 |  |  |  | 172.71d | finish no earlier than 2010-09-30 |  |
| 55 | 1.4.2 | Construction Phase MS Project WSB Template | 175.86d | 2010-03-01 | 2010-09-30 |  |  |  | 172.71d | finish no earlier than 2010-09-30 |  |
| 56 | 1.4.3 | Construction Phase Project Team Wheel | 175.86d | 2010-03-01 | 2010-09-30 |  |  |  | 172.71d | finish no earlier than 2010-09-30 |  |
| 57 | 1.4.4 | Disaster Recovery Plan | 175.86d | 2010-03-01 | 2010-09-30 |  |  |  | 172.71d | finish no earlier than 2010-09-30 |  |
| 58 | 1.4.5 | Environmental Migration Checklist | 175.86d | 2010-03-01 | 2010-09-30 |  |  |  | 172.71d | finish no earlier than 2010-09-30 |  |
| 59 | 1.4.6 | Test Case Template | 175.86d | 2010-03-01 | 2010-09-30 |  |  |  | 172.71d | finish no earlier than 2010-09-30 |  |
| 60 | 1.4.7 | Training Plan | 175.86d | 2010-03-01 | 2010-09-30 |  |  |  | 172.71d | finish no earlier than 2010-09-30 |  |
| 61 | 1.4.8 | Phase End Decision Point Meeting | 175.86d | 2010-03-01 | 2010-09-30 |  |  |  | 172.71d | finish no earlier than 2010-09-30 |  |
| 62 | 1.5 | **Subtask 1E - DOIT Testing Phase Deliverables** | 75.29d | 2010-10-01 | 2010-12-31 | 2008-07-11 | 2010-01-15 | 452.14d? | 97.29d |  | 5,905,525 |
| 63 | 1.5.1 | Defect Summary by Plan | 75.29d | 2010-10-01 | 2010-12-31 |  |  |  | 97.29d | finish no earlier than 2010-12-31 |  |
| 64 | 1.5.2 | Environment Migration Checklist | 75.29d | 2010-10-01 | 2010-12-31 |  |  |  | 97.29d | finish no earlier than 2010-12-31 |  |
| 65 | 1.5.3 | Production Support and Administration Document | 75.29d | 2010-10-01 | 2010-12-31 |  |  |  | 97.29d | finish no earlier than 2010-12-31 |  |
| 66 | 1.5.4 | System Bill of Materials | 75.29d | 2010-10-01 | 2010-12-31 |  |  |  | 97.29d | finish no earlier than 2010-12-31 |  |
| 67 | 1.5.5 | Test Case Execution Summary | 75.29d | 2010-10-01 | 2010-12-31 |  |  |  | 97.29d | finish no earlier than 2010-12-31 |  |
| 68 | 1.5.6 | Testing Phase MS Project WSB Template | 75.29d | 2010-10-01 | 2010-12-31 |  |  |  | 97.29d | finish no earlier than 2010-12-31 |  |
| 69 | 1.5.7 | Testing Phase Project Team Wheel | 75.29d | 2010-10-01 | 2010-12-31 |  |  |  | 97.29d | finish no earlier than 2010-12-31 |  |
| 70 | 1.5.8 | Phase End Decision Point Meeting | 75.29d | 2010-10-01 | 2010-12-31 |  |  |  | 97.29d | finish no earlier than 2010-12-31 |  |
| 71 | 1.5.9 | **Pilot Project # 1 - Define Goals/Benchmarks** | 75.29d | 2010-10-01 | 2010-12-31 | 2008-07-11 | 2009-05-06 | 244.14d | 97.29d |  | 1,370,050 |
| 72 | 1.5.9.1 | Goals - | 75.29d | 2010-10-01 | 2010-12-31 | 2008-07-11 | 2008-08-01 | 17.14d | 97.29d | finish no earlier than 2010-12-31 | 15,900 |
| 73 | 1.5.9.2 | Goals - | 75.29d | 2010-10-01 | 2010-12-31 | 2008-09-04 | 2008-11-17 | 60d | 97.29d | finish no earlier than 2010-12-31 | 55,650 |
| 74 | 1.5.9.3 | Goals - | 75.29d | 2010-10-01 | 2010-12-31 | 2008-09-04 | 2009-05-06 | 200d | 97.29d | finish no earlier than 2010-12-31 | 185,500 |
| 75 | 1.5.9.4 | Goals - | 75.29d | 2010-10-01 | 2010-12-31 | 2008-09-04 | 2009-05-06 | 200d | 97.29d | finish no earlier than 2010-12-31 | 185,500 |
| 76 | 1.5.9.5 | Goals - | 75.29d | 2010-10-01 | 2010-12-31 | 2008-09-04 | 2009-05-06 | 200d | 97.29d | finish no earlier than 2010-12-31 | 185,500 |
| 77 | 1.5.9.6 | Goals - | 75.29d | 2010-10-01 | 2010-12-31 | 2008-09-04 | 2009-05-06 | 200d | 97.29d | finish no earlier than 2010-12-31 | 185,500 |
| 78 | 1.5.9.7 | Goals - | 74.14d | 2010-10-04 | 2010-12-31 | 2008-09-04 | 2009-05-06 | 200d | 97.29d | finish no earlier than 2010-12-31 | 185,500 |
| 79 | 1.5.9.8 | Goals - | 75.29d | 2010-10-01 | 2010-12-31 | 2008-09-04 | 2009-05-06 | 200d | 97.29d | finish no earlier than 2010-12-31 | 185,500 |
| 80 | 1.5.9.9 | Goals - | 75.29d | 2010-10-01 | 2010-12-31 | 2008-09-04 | 2009-05-06 | 200d | 97.29d | finish no earlier than 2010-12-31 | 185,500 |

| ID | WBS | Task | Duration | Start | Finish | Baseline start | Baseline finish | Baseline duration | Total slack | Constraint | Resources | Work | Cost | Baseline cost |
| --- | --- | --- | --- | --- | --- | --- | --- | --- | --- | --- | --- | --- | --- | --- |
| 81 | 1.5.10 | **Pilot Project # 2 - Define Goals/Benchmarks** | 75.29d | 2010-10-01 | 2010-12-31 | 2008-11-17 | 2009-08-24 | 229.71d? | 97.29d |  |  |  |  | 1,511,825 |
| 82 | 1.5.10.1 | Goals - | 75.29d | 2010-10-01 | 2010-12-31 | 2008-11-17 | 2008-12-23 | 30d? | 97.29d | finish no earlier than 2010-12-31 |  |  |  | 27,825 |
| 83 | 1.5.10.2 | Goals - | 75.29d | 2010-10-01 | 2010-12-31 | 2008-12-23 | 2009-08-24 | 200d | 97.29d | finish no earlier than 2010-12-31 |  |  |  | 185,500 |
| 84 | 1.5.10.3 | Goals - | 75.29d | 2010-10-01 | 2010-12-31 | 2008-12-23 | 2009-08-24 | 200d | 97.29d | finish no earlier than 2010-12-31 |  |  |  | 185,500 |
| 85 | 1.5.10.4 | Goals - | 75.29d | 2010-10-01 | 2010-12-31 | 2008-12-23 | 2009-08-24 | 200d | 97.29d | finish no earlier than 2010-12-31 |  |  |  | 185,500 |
| 86 | 1.5.10.5 | Goals - | 75.29d | 2010-10-01 | 2010-12-31 | 2008-12-23 | 2009-08-24 | 200d | 97.29d | finish no earlier than 2010-12-31 |  |  |  | 185,500 |
| 87 | 1.5.10.6 | Goals - | 75.29d | 2010-10-01 | 2010-12-31 | 2008-12-23 | 2009-08-24 | 200d | 97.29d | finish no earlier than 2010-12-31 |  |  |  | 185,500 |
| 88 | 1.5.10.7 | Goals - | 75.29d | 2010-10-01 | 2010-12-31 | 2008-12-23 | 2009-08-24 | 200d | 97.29d | finish no earlier than 2010-12-31 |  |  |  | 185,500 |
| 89 | 1.5.10.8 | Goals - | 75.29d | 2010-10-01 | 2010-12-31 | 2008-12-23 | 2009-08-24 | 200d | 97.29d | finish no earlier than 2010-12-31 |  |  |  | 185,500 |
| 90 | 1.5.10.9 | Goals - | 75.29d | 2010-10-01 | 2010-12-31 | 2008-12-23 | 2009-08-24 | 200d | 97.29d | finish no earlier than 2010-12-31 |  |  |  | 185,500 |
| 91 | 1.6 | **Subtask 1F - DOIT Implementation Phase Deliverables** | 73d | 2011-01-03 | 2011-03-31 | 2008-07-11 | 2010-01-15 | 452.14d? | 24.14d |  |  |  |  | 5,905,525 |
| 92 | 1.6.1 | Implementaion Phase MS Project WSB Template | 73d | 2011-01-03 | 2011-03-31 |  |  |  | 24.14d | finish no earlier than 2011-03-31 |  |  |  |  |
| 93 | 1.6.2 | Implementation Phase Project Team Wheel | 73d | 2011-01-03 | 2011-03-31 |  |  |  | 24.14d | finish no earlier than 2011-03-31 |  |  |  |  |
| 94 | 1.6.3 | Phase End Decision Point Meeting | 73d | 2011-01-03 | 2011-03-31 |  |  |  | 24.14d | start no earlier than 2011-01-01 |  |  |  |  |
| 95 | 1.7 | **Subtask 1G - DOIT Post Implementation Phase Deliverables** | 24d | 2011-04-01 | 2011-04-30 | 2008-07-11 | 2010-01-15 | 452.14d? | 0d |  |  |  |  | 5,905,525 |
| 96 | 1.7.1 | Implementaion Phase MS Project WSB Template | 24d | 2011-04-01 | 2011-04-30 |  |  |  | 0d | finish no earlier than 2011-04-30 |  |  |  |  |
| 97 | 1.7.2 | Project Summary Template | 24d | 2011-04-01 | 2011-04-30 |  |  |  | 0d | finish no earlier than 2011-04-30 |  |  |  |  |
| 98 | 1.8 | Phase End Decision Point Meeting | 2.14d | 2010-04-29 | 2010-04-30 |  |  |  | 297.29d | start no earlier than 2010-04-29 | Zimmerman Kathleen A.; Molina John | 30h | 1,125 |  |
